# DDEP_exercise_1_E15-16_solution

Schedule from MS Project, 2016-04-15 to 2016-05-20, costs in €.
TEI

## Calendars

- Standard: Mon-Fri 08:00-16:00; Sat-Sun off.

## Resources

| Resource | Rate |
| --- | --- |
| Ομαδάρχης | 20 |
| Μηχανικός Ποιότητας | 15 |
| Μηχανικός Λογισμικού | 15 |
| Προγραμματιστής | 10 |

## Schedule

| ID | WBS | Task | Duration | Start | Finish | Predecessors | Total slack | Resources | Work | Cost |
| --- | --- | --- | --- | --- | --- | --- | --- | --- | --- | --- |
| 1 | 1 | **Καθορισμός εργασιών** | 2d | 2016-04-15 | 2016-04-18 |  | 0d |  | 16h | 280 |
| 2 | 1.1 | Καθορισμός καθήκοντων | 1d | 2016-04-15 | 2016-04-15 |  | 0d | Ομαδάρχης | 8h | 160 |
| 3 | 1.2 | Καθορισμός διεργασιών | 1d | 2016-04-18 | 2016-04-18 | 2 | 0d | Μηχανικός Ποιότητας | 8h | 120 |
| 4 | 2 | **Ανάλυση απαιτήσεων** | 2d | 2016-04-19 | 2016-04-20 |  | 0d |  | 32h | 520 |
| 5 | 2.1 | Δημιουργία Λίστας Απαιτήσεων | 1d | 2016-04-19 | 2016-04-19 | 3 | 0d | Μηχανικός Ποιότητας | 8h | 120 |
| 6 | 2.2 | Καθορισμός Ποιοτικών Χαρακτηριστικών | 1d | 2016-04-20 | 2016-04-20 | 5 | 22d | Ομαδάρχης; Μηχανικός Ποιότητας | 16h | 280 |
| 7 | 2.3 | Καθορισμός Μετικών | 1d | 2016-04-20 | 2016-04-20 | 5 | 0d | Μηχανικός Λογισμικού | 8h | 120 |
| 8 | 3 | **Σχεδιασμός** | 5d | 2016-04-21 | 2016-04-27 |  | 0d |  | 40h | 600 |
| 9 | 3.1 | Γενικός Σχεδιασμός | 2d | 2016-04-21 | 2016-04-22 | 7 | 0d | Μηχανικός Λογισμικού | 16h | 240 |
| 10 | 3.2 | Λεπτομερής Σχεδιασμός | 3d | 2016-04-25 | 2016-04-27 | 9 | 0d | Μηχανικός Λογισμικού | 24h | 360 |
| 11 | 4 | **Προγραμματισμός** | 15d | 2016-04-28 | 2016-05-18 |  | 0d |  | 120h | 1,200 |
| 12 | 4.1 | Κωδικκοποίηση | 13d | 2016-04-28 | 2016-05-16 | 10 | 0d | Προγραμματιστής | 104h | 1,040 |
| 13 | 4.2 | Έλεγχος Κώδικα | 2d | 2016-05-17 | 2016-05-18 | 12 | 2d | Προγραμματιστής | 16h | 160 |
| 14 | 5 | **Αναθεώρηση** | 4d | 2016-05-17 | 2016-05-20 |  | 0d |  | 40h | 640 |
| 15 | 5.1 | Έλεγχος τήρησης απαιτήσεων | 3d | 2016-05-17 | 2016-05-19 | 12 | 0d | Μηχανικός Ποιότητας | 24h | 360 |
| 16 | 5.2 | Τελικός Έλεγχος | 1d | 2016-05-20 | 2016-05-20 | 15 | 0d | Ομαδάρχης; Μηχανικός Ποιότητας | 16h | 280 |
